# ГПР переезд 8

Schedule from MS Project, 2024-07-05 to 2024-07-11.

## Calendars

- Копия Стандартный: Mon-Sun 09:00-13:00, 14:00-18:00.

## Schedule

| ID | WBS | Task | Duration | Start | Finish | Predecessors | Total slack |
| --- | --- | --- | --- | --- | --- | --- | --- |
| 1 | 1 | **Ремонт аварийного переезда ЖД путей №30 у ЖДЦ** | 7d | 2024-07-05 | 2024-07-11 |  | 0d |
| 2 | 1.1 | **Демонтажные работы** | 2d | 2024-07-05 | 2024-07-06 |  | 0d |
| 3 | 1.1.1 | Разборка асфальтобетонного покрытия | 2d | 2024-07-05 | 2024-07-06 |  | 5d |
| 4 | 1.1.2 | Разборка щебеночного основания | 2d | 2024-07-05 | 2024-07-06 |  | 5d |
| 5 | 1.1.3 | Очистка пути, межшпальных ящиков и площади под укладку наружных плит переезда от песка и щебня | 2d | 2024-07-05 | 2024-07-06 |  | 5d |
| 6 | 1.1.4 | Демонтаж железобетонных шпал | 2d | 2024-07-05 | 2024-07-06 |  | 5d |
| 7 | 1.1.5 | Демонтаж рельс 12,5м | 2d | 2024-07-05 | 2024-07-06 |  | 0d |
| 8 | 1.2 | **Строительные работы** | 2d | 2024-07-07 | 2024-07-08 |  | 0d |
| 9 | 1.2.1 | Укладка железобетонных шпал, с комплектом крепления КБ-65 | 1d | 2024-07-07 | 2024-07-07 | 7 | 0d |
| 10 | 1.2.2 | Монтаж рельс Р65 12,5м | 1d | 2024-07-07 | 2024-07-07 | 9SS | 0d |
| 11 | 1.2.3 | Выправка и рихтовка ж/д пути на ж/б шпалах | 1d | 2024-07-08 | 2024-07-08 | 10 | 0d |
| 12 | 1.3 | **Укладка резиножелезобетонного переезда L=6,5м** | 1d | 2024-07-09 | 2024-07-09 |  | 0d |
| 13 | 1.3.1 | укладка плиты внутренней ПЖДв (3,25м. Х 1,58м. Х 0,17м.) - 2 шт. | 1d | 2024-07-09 | 2024-07-09 | 11 | 0d |
| 14 | 1.3.2 | укладка плиты наружней ПЖДн (3,25м. Х 0,8м. Х 0,17м.) - 4 шт. | 1d | 2024-07-09 | 2024-07-09 | 11 | 0d |
| 15 | 1.3.3 | устройство полосы резиновой (3250 х 80 х 10)мм. Для внутренних плит - 8 шт. | 1d | 2024-07-09 | 2024-07-09 | 13SS | 0d |
| 16 | 1.3.4 | устройство полосы резиновой (3250 х 80 х 10)мм. Для наружных плит - 8 шт. | 1d | 2024-07-09 | 2024-07-09 | 14SS | 0d |
| 17 | 1.3.5 | устройство упоров фиксации резиножелезобетонных плит 2 шт. | 1d | 2024-07-09 | 2024-07-09 | 16SS | 0d |
| 18 | 1.4 | **Устройство асфальтового покрытия на подходах к переезду** | 2d | 2024-07-10 | 2024-07-11 |  | 0d |
| 19 | 1.4.1 | Устройство подстилающего слоя из песка, толщиной 100 мм | 1d | 2024-07-10 | 2024-07-10 | 12 | 1d |
| 20 | 1.4.2 | Устройство щебёночного основания, толщиной 150 мм | 1d | 2024-07-10 | 2024-07-10 | 12 | 0d |
| 21 | 1.4.3 | Асфальтировка переезда в два слоя | 1d | 2024-07-11 | 2024-07-11 | 20 | 0d |
